# ADUCCIÓN GUÁTICA

Schedule from MS Project, 2026-05-12 to 2026-09-23, costs in $.

## Calendars

- Corrido: Mon-Sun 07:00-12:00, 14:00-17:00.

## Schedule

| ID | WBS | Task | Type | Duration | Start | Finish | Predecessors | Total slack | Free slack | Cost |
| --- | --- | --- | --- | --- | --- | --- | --- | --- | --- | --- |
| 1 | 1 | INICIO | milestone | 0d | 2026-05-12 | 2026-05-12 |  | 0d |  |  |
| 2 | 2 | **PRELIMINARES** |  | 135d | 2026-05-12 | 2026-09-23 |  | 0d |  | 151,243,801 |
| 3 | 2.1 | LOCALIZACIÓN Y REPLANTEO DE LÍNEA |  | 7d | 2026-05-12 | 2026-05-18 | 1 | 1d | 0d | 18,696,994 |
| 4 | 2.2 | LOCALIZACIÓN Y REPLANTEO DE OBRA |  | 7d | 2026-05-12 | 2026-05-18 | 1 | 128d |  | 117,749 |
| 5 | 2.3 | ALQUILER DE ALMACEN/CAMPAMENTO |  | 135d | 2026-05-12 | 2026-09-23 | 1 | 0d |  | 3,873,336 |
| 6 | 2.4 | CERRAMIENTO PROVISIONAL CON DELINEADOR TUBULAR TIPO COLOMBINA Y MALLA PLÁSTICA DE CONSTRUCCIÓN H=1.2M, INCLUYE ACARREO HORIZONTAL EN OBRA |  | 127d | 2026-05-19 | 2026-09-22 | 3 | 1d | 0d | 17,743,924 |
| 7 | 2.5 | CUBIERTA PROVISIONAL POLETILENO CAL 4 Y GUADUA |  | 127d | 2026-05-19 | 2026-09-22 | 6SS | 1d |  | 91,128,096 |
| 8 | 2.6 | ROCERÍA Y LIMPIEZA |  | 127d | 2026-05-19 | 2026-09-22 | 6SS | 1d | 0d | 19,683,702 |
| 9 | 3 | **MOVIMIENTO DE TIERRA** |  | 134d | 2026-05-12 | 2026-09-22 |  | 1d |  | 623,133,332 |
| 10 | 3.1 | EXCAVACIÓN MANUAL EN MATERIAL COMÚN 0 - 2 M |  | 115d | 2026-05-26 | 2026-09-17 | 8SS+7d | 1d | 0d | 70,732,435 |
| 11 | 3.2 | EXCAVACIÓN EN MATERIAL CONGLOMERADO 0 - 2 M - MANUAL |  | 115d | 2026-05-26 | 2026-09-17 | 8SS+7d | 6d |  | 109,426,774 |
| 12 | 3.3 | EXCAVACIÓN EN FRAGMENTOS DE ROCA Ø > 0.50 M |  | 115d | 2026-05-26 | 2026-09-17 | 8SS+7d | 6d |  | 162,760,976 |
| 13 | 3.4 | EXCAVACIÓN MECÁNICA DE MICROPILOTE Ø0.50 M |  | 30d | 2026-06-15 | 2026-07-14 | 10SS+20d | 34d | 0d | 29,523,788 |
| 14 | 3.5 | ENTIBADO DISCONTINUO EN MADERA (TIPO 1A) |  | 115d | 2026-05-26 | 2026-09-17 | 10SS | 6d |  | 28,135,192 |
| 15 | 3.6 | SUMINISTRO Y COLOCACIÓN DE ARENA GRUESA PARA SOPORTE Y PROTECCION DE TUBERÍAS |  | 110d | 2026-06-02 | 2026-09-19 | 10SS+7d | 4d | 0d | 50,586,799 |
| 16 | 3.7 | LLENO COMPACTADO CON MATERIAL DEL SITIO |  | 134d | 2026-05-12 | 2026-09-22 |  | 1d | 0d | 113,098,286 |
| 17 | 3.8 | CARGUE Y RETIRO DE MATERIAL SOBRANTE (A BOTADERO AUTORIZADO - PEREIRA RISARALDA) |  | 110d | 2026-05-31 | 2026-09-17 | 10SS+5d | 6d | 0d | 56,044,944 |
| 18 | 3.9 | DISPOSICIÓN FINAL EN BOTADERO AUTORIZADO - PEREIRA RISARALDA |  | 110d | 2026-05-31 | 2026-09-17 | 17SS | 6d |  | 2,824,138 |
| 19 | 4 | **SUMINISTRO E INSTALACIÓN DE TUBERÍAS Y ACCESORIOS** |  | 100d | 2026-06-05 | 2026-09-12 |  | 11d |  | 523,670,643 |
| 20 | 4.1 | ADAPTADOR HD Ø3", EXTREMO BRIDA X UNIVERSAL |  | 80d | 2026-06-25 | 2026-09-12 | 31SS+20d | 11d |  | 329,351 |
| 21 | 4.2 | ADAPTADOR HD Ø4", EXTREMO BRIDA X UNIVERSAL |  | 80d | 2026-06-25 | 2026-09-12 | 31SS+20d | 11d |  | 788,445 |
| 22 | 4.3 | ADAPTADOR HD Ø6", EXTREMO BRIDA X UNIVERSAL |  | 80d | 2026-06-25 | 2026-09-12 | 31SS+20d | 11d |  | 426,658 |
| 23 | 4.4 | BRIDA METÁLICA Ø3" |  | 80d | 2026-06-25 | 2026-09-12 | 31SS+20d | 11d |  | 151,450 |
| 24 | 4.5 | BRIDA METÁLICA Ø4" |  | 80d | 2026-06-25 | 2026-09-12 | 31SS+20d | 11d |  | 2,022,260 |
| 25 | 4.6 | BRIDA METÁLICA Ø6" |  | 80d | 2026-06-25 | 2026-09-12 | 31SS+20d | 11d |  | 1,218,178 |
| 26 | 4.7 | CODO 45° PEAD PN10 DN 160 mm (Ø6") |  | 80d | 2026-06-25 | 2026-09-12 | 31SS+20d | 11d |  | 4,742,943 |
| 27 | 4.8 | PORTABRIDA PEAD PN 10 DN 160 mm (Ø6") |  | 80d | 2026-06-25 | 2026-09-12 | 31SS+20d | 11d |  | 1,763,723 |
| 28 | 4.9 | PORTABRIDA PEAD PN 10 DN 75 mm (Ø3") |  | 80d | 2026-06-25 | 2026-09-12 | 31SS+20d | 11d |  | 176,379 |
| 29 | 4.10 | PORTABRIDA PEAD PN 16 DN 160 mm (Ø4") |  | 80d | 2026-06-25 | 2026-09-12 | 31SS+20d | 11d |  | 4,023,983 |
| 30 | 4.11 | REDUCCIÓN PEAD PN10 Ø6" x 3" |  | 80d | 2026-06-25 | 2026-09-12 | 31SS+20d | 11d |  | 316,054 |
| 31 | 4.12 | SUMINISTRO E INSTALACIÓN DE TUBERÍA PEAD PN10 DN 75 mm (Ø3"), INCLUYE TERMOFUSION |  | 100d | 2026-06-05 | 2026-09-12 | 15SS+3d | 11d | 0d | 1,867,981 |
| 32 | 4.13 | SUMINISTRO E INSTALACIÓN DE TUBERÍA PEAD PN10 DN 110 mm (Ø4"), INCLUYE TERMOFUSION |  | 100d | 2026-06-05 | 2026-09-12 | 31SS | 11d |  | 218,473,358 |
| 33 | 4.14 | SUMINISTRO E INSTALACIÓN DE TUBERÍA PEAD PN10 DN 160 mm (Ø6"), INCLUYE TERMOFUSION |  | 100d | 2026-06-05 | 2026-09-12 | 31SS | 11d |  | 75,509,110 |
| 34 | 4.15 | SUMINISTRO E INSTALACIÓN DE TUBERÍA PEAD PN12.5 DN 110 mm (Ø4"), INCLUYE TERMOFUSION |  | 100d | 2026-06-05 | 2026-09-12 | 31SS | 11d |  | 72,066,857 |
| 35 | 4.16 | SUMINISTRO E INSTALACIÓN DE TUBERÍA PEAD PN16 DN 110 mm (Ø4"), INCLUYE TERMOFUSION |  | 100d | 2026-06-05 | 2026-09-12 | 31SS | 11d |  | 107,218,241 |
| 36 | 4.17 | TEE REDUCIDA HD Ø4" x Ø2", EXTREMO BRIDA |  | 80d | 2026-06-25 | 2026-09-12 | 31SS+20d | 11d |  | 3,644,990 |
| 37 | 4.18 | TEE REDUCIDA HD Ø6" x Ø4", EXTREMO BRIDA |  | 80d | 2026-06-25 | 2026-09-12 | 31SS+20d | 11d |  | 2,222,207 |
| 38 | 4.19 | VÁLVULA DE COMPUERTA Ø2", EXTREMO BRIDA |  | 80d | 2026-06-25 | 2026-09-12 | 31SS+20d | 11d |  | 3,733,130 |
| 39 | 4.20 | VÁLVULA DE COMPUERTA Ø4", EXTREMO BRIDA |  | 80d | 2026-06-25 | 2026-09-12 | 31SS+20d | 11d |  | 7,738,073 |
| 40 | 4.21 | VÁLVULA DE COMPUERTA Ø6", EXTREMO BRIDA |  | 80d | 2026-06-25 | 2026-09-12 | 31SS+20d | 11d |  | 4,119,195 |
| 41 | 4.22 | VENTOSA TRIPLE ACCIÓN Ø2", EXTREMO BRIDA |  | 80d | 2026-06-25 | 2026-09-12 | 31SS+20d | 11d |  | 6,821,340 |
| 42 | 4.23 | VENTOSA TRIPLE ACCIÓN Ø4", EXTREMO BRIDA |  | 80d | 2026-06-25 | 2026-09-12 | 31SS+20d | 11d |  | 4,296,737 |

| ID | WBS | Task | Type | Duration | Start | Finish | Predecessors | Total slack | Free slack | Cost |
| --- | --- | --- | --- | --- | --- | --- | --- | --- | --- | --- |
| 43 | 5 | **ACERO DE REFUERZO** |  | 90d | 2026-06-10 | 2026-09-07 |  | 1d |  | 37,619,542 |
| 44 | 5.1 | SUMINISTRO E INSTALACIÓN DE ACERO Fy = 60.000 PSI D > 1/4" |  | 90d | 2026-06-10 | 2026-09-07 | 10SS+15d | 1d | 0d | 37,619,542 |
| 45 | 6 | **OBRAS EN CONCRETO** |  | 95d | 2026-06-05 | 2026-09-07 |  | 6d |  | 26,784,490 |
| 46 | 6.1 | CAJA DE INSPECCIÓN DE 1.10 x 1.10 x 1.10 m, EN CONCRETO F'C 28 MPA (4000 PSI), INCLUYE ACARREO HORIZONTAL EN OBRA |  | 90d | 2026-06-10 | 2026-09-07 | 44SS | 1d | 0d | 10,375,908 |
| 47 | 6.2 | CONCRETO PARA SILLETAS, ATRAQUES Y ANCLAJES (CONCRETO 21 MPA) |  | 90d | 2026-06-05 | 2026-09-02 | 31SS | 21d |  | 1,800,167 |
| 48 | 6.3 | CONCRETO APOYO DE VIADUCTO (PEDESTALES - PILOTES) F'C 24 MPA (3500 PSI), INCLUYE ACARREO HORIZONTAL EN OBRA |  | 30d | 2026-06-22 | 2026-07-21 | 13SS+7d | 34d | 0d | 14,608,415 |
| 49 | 7 | **VARIOS** |  | 89d | 2026-06-26 | 2026-09-22 |  | 1d |  | 17,348,528 |
| 50 | 7.1 | SUMINISTRO E INSTALACIÓN DE TAPA EN LAMINA DE ALFAJOR PARA CAJA DE VALVULA 0.95 X 0.95, INCLUYE ACARREO HORIZONTAL EN OBRA |  | 15d | 2026-09-08 | 2026-09-22 | 46 | 1d |  | 8,333,841 |
| 51 | 7.2 | SUMINISTRO Y SIEMBRA DE ARBÓLES H<=1M, INCLUYE INSUMOS, MANO DE OBRA, EXCAVACIÓN, ABONO Y HERRAMIENTAS |  | 80d | 2026-06-26 | 2026-09-13 | 16SS+45d | 10d |  | 9,014,687 |
| 52 | 8 | **VIADUCTOS** |  | 30d | 2026-07-22 | 2026-08-20 |  | 34d |  | 328,735,232 |
| 53 | 8.1 | SUMINISTRO E INSTALACIÓN DE ACERO ESTRUCTURAL TIPO ACERO ASTM A-572 G50 Fy=3.500 kg/cm2, PARA PERFILES ANGULARES DE VIADUCTO (INCLUYE ACABADO EN ANTICORROSIVO), INCLUYE ACARREO HORIZONTAL EN OBRA |  | 30d | 2026-07-22 | 2026-08-20 | 48 | 34d |  | 227,678,287 |
| 54 | 8.2 | SUMINISTRO E INSTALACIÓN DE ACERO ESTRUCTURAL TIPO ACERO ASTM A-572 Fy=2.520 kg/cm2, PARA TENSORES, RIOSTRAS, LAMINAS Y PLATINAS DE VIADUCTO (INCLUYE ACABADO EN ANTICORROSIVO), INCLUYE ACARREO HORIZONTAL EN OBRA |  | 30d | 2026-07-22 | 2026-08-20 | 48 | 34d |  | 101,056,945 |
| 55 | 9 | **SEÑALIZACIÓN VIAL Y COMPONENTE AMBIENTAL** |  | 127d | 2026-05-19 | 2026-09-22 |  | 1d |  | 1,274,505 |
| 56 | 9.1 | SEÑAL VIAL VERTICAL REFLECTIVA TIPO PARAL TEMPORAL |  | 127d | 2026-05-19 | 2026-09-22 | 6SS | 1d |  | 1,274,505 |
| 57 | 10 | **IMPLEMENTACIÓN DE PLANES** |  | 135d | 2026-05-12 | 2026-09-23 |  | 0d |  | 38,733,360 |
| 58 | 10.1 | IMPLEMENTACIÓN Y SEGUIMIENTO AL PLAN DE GESTIÓN SOCIAL |  | 135d | 2026-05-12 | 2026-09-23 | 1 | 0d |  | 12,911,120 |
| 59 | 10.2 | IMPLEMENTACIÓN Y SEGUIMIENTO AL PLAN DE GESTIÓN AMBIENTAL |  | 135d | 2026-05-12 | 2026-09-23 | 1 | 0d |  | 12,911,120 |
| 60 | 10.3 | IMPLEMENTACIÓN Y SEGUIMIENTO AL PLAN DE GESTIÓN EN SEGURIDAD Y SALUD |  | 135d | 2026-05-12 | 2026-09-23 | 1 | 0d |  | 12,911,120 |
| 61 | 11 | FIN | milestone | 0d | 2026-09-23 | 2026-09-23 | 4, 5, 7, 11, 12, 14, 18, 20, 21, 22, 23, 24, 25, 26, 27, 28, 29, 30, 32, 33, 34, 35, 36, 37, 38, 39, 40, 41, 42, 47, 50, 51, 53, 54, 56, 58, 59, 60 | 0d |  |  |
